# Project template

Schedule from MS Project, 2002-01-01 to 2002-06-26.
Microsoft Project

## Calendars

- Standard: Mon-Fri 08:00-12:00, 13:00-17:00; Sat-Sun off.
- NG - Day shift: Mon-Fri 09:00-13:00, 14:00-18:00; Sat-Sun off. Exceptions (off unless hours are given): 2002-01-05 09:00-13:00, 14:00-18:00, 2002-01-19 09:00-13:00, 14:00-18:00, 2002-02-02 09:00-13:00, 14:00-18:00, 2002-02-16 09:00-13:00, 14:00-18:00, 2002-03-02 09:00-13:00, 14:00-18:00, 2002-03-16 09:00-13:00, 14:00-18:00, 2002-03-30 09:00-13:00, 14:00-18:00, 2002-04-13 09:00-13:00, 14:00-18:00, 2002-04-27 09:00-13:00, 14:00-18:00, 2002-05-11 09:00-13:00, 14:00-18:00, 2002-05-25 09:00-13:00, 14:00-18:00, 2002-06-08 09:00-13:00, 14:00-18:00, 2002-06-22 09:00-13:00, 14:00-18:00.

## Schedule

| ID | WBS | Task | Type | Duration | Start | Finish | Predecessors | Baseline start | Baseline finish | Baseline duration | Total slack | Free slack | Constraint | Calendar |
| --- | --- | --- | --- | --- | --- | --- | --- | --- | --- | --- | --- | --- | --- | --- |
| 1 | 1 | Refer the note for colour codes ! |  | 8h? | 2002-01-01 | 2002-01-02 |  |  |  |  | 125.88d |  |  |  |
| 2 | 2 | **GENERAL TASKS** |  | 15.88d? | 2002-01-01 | 2002-01-22 |  | 2001-10-29 | 2002-01-14 | 56d? | 0d |  |  |  |
| 3 | 2.1 | **Contract / work order** |  | 11.88d? | 2002-01-01 | 2002-01-16 |  | 2001-10-29 | 2001-11-14 | 13d? | 0d |  |  |  |
| 4 | 2.1.1 | Preparation of work order |  | 1d? | 2002-01-01 | 2002-01-02 |  | 2001-10-29 | 2001-10-29 | 1d? | 0d |  |  |  |
| 5 | 2.1.2 | Preparation of contract |  | 1d? | 2002-01-02 | 2002-01-03 | 4 | 2001-10-30 | 2001-10-30 | 1d? | 0d |  |  |  |
| 6 | 2.1.3 | **Follow-up for work order sign off** |  | 4d? | 2002-01-03 | 2002-01-07 |  | 2001-10-31 | 2001-11-05 | 4d? | 0d |  |  | NG - Day shift |
| 7 | 2.1.3.1 | Follow-up for work order sign off 1 |  | 1d? | 2002-01-03 | 2002-01-03 | 5 | 2001-10-31 | 2001-10-31 | 1d? | 0d |  | start no earlier than 2002-01-01 | NG - Day shift |
| 8 | 2.1.3.2 | Follow-up for work order sign off 2 |  | 1d? | 2002-01-04 | 2002-01-04 | 7 | 2001-11-01 | 2001-11-01 | 1d? | 0d |  | start no earlier than 2002-01-02 | NG - Day shift |
| 9 | 2.1.3.3 | Follow-up for work order sign off 3 |  | 1d? | 2002-01-05 | 2002-01-05 | 8 | 2001-11-02 | 2001-11-02 | 1d? | 0d |  | start no earlier than 2002-01-03 | NG - Day shift |
| 10 | 2.1.3.4 | Follow-up for work order sign off 4 |  | 1d? | 2002-01-07 | 2002-01-07 | 9 | 2001-11-05 | 2001-11-05 | 1d? | 0d |  | start no earlier than 2002-01-04 | NG - Day shift |
| 11 | 2.1.4 | Work order signed off | milestone | 0d | 2002-01-07 | 2002-01-07 | 10 | 2001-11-05 | 2001-11-05 | 0d | 0.12d | 0d |  |  |
| 12 | 2.1.5 | **Follow-up for advance payment** |  | 4d? | 2002-01-08 | 2002-01-11 |  | 2001-11-06 | 2001-11-09 | 4d? | 129.88d |  |  | NG - Day shift |
| 13 | 2.1.5.1 | Follow-up for advance payment 1 |  | 1d? | 2002-01-08 | 2002-01-08 | 11 | 2001-11-06 | 2001-11-06 | 1d? | 129.88d | 0.12d | start no earlier than 2002-01-01 | NG - Day shift |
| 14 | 2.1.5.2 | Follow-up for advance payment 2 |  | 1d? | 2002-01-09 | 2002-01-09 | 13 | 2001-11-07 | 2001-11-07 | 1d? | 129.88d | 0.12d | start no earlier than 2002-01-02 | NG - Day shift |
| 15 | 2.1.5.3 | Follow-up for advance payment 3 |  | 1d? | 2002-01-10 | 2002-01-10 | 14 | 2001-11-08 | 2001-11-08 | 1d? | 129.88d | 0.12d | start no earlier than 2002-01-03 | NG - Day shift |
| 16 | 2.1.5.4 | Follow-up for advance payment 4 |  | 1d? | 2002-01-11 | 2002-01-11 | 15 | 2001-11-09 | 2001-11-09 | 1d? | 129.88d | 0d | start no earlier than 2002-01-04 | NG - Day shift |
| 17 | 2.1.6 | Advance received | milestone | 0d | 2002-01-11 | 2002-01-11 | 16 | 2001-11-09 | 2001-11-09 | 0d | 118d |  |  |  |
| 18 | 2.1.7 | **Follow-up for contract sign off** |  | 7d? | 2002-01-08 | 2002-01-16 |  | 2001-11-06 | 2001-11-14 | 7d? | 126.88d |  |  | NG - Day shift |
| 19 | 2.1.7.1 | Follow-up for contract sign off 1 |  | 1d? | 2002-01-08 | 2002-01-08 | 11 | 2001-11-06 | 2001-11-06 | 1d? | 126.88d | 0.12d | start no earlier than 2002-01-01 | NG - Day shift |
| 20 | 2.1.7.2 | Follow-up for contract sign off 2 |  | 1d? | 2002-01-09 | 2002-01-09 | 19 | 2001-11-07 | 2001-11-07 | 1d? | 126.88d | 0.12d | start no earlier than 2002-01-02 | NG - Day shift |
| 21 | 2.1.7.3 | Follow-up for contract sign off 3 |  | 1d? | 2002-01-10 | 2002-01-10 | 20 | 2001-11-08 | 2001-11-08 | 1d? | 126.88d | 0.12d | start no earlier than 2002-01-03 | NG - Day shift |
| 22 | 2.1.7.4 | Follow-up for contract sign off 4 |  | 1d? | 2002-01-11 | 2002-01-11 | 21 | 2001-11-09 | 2001-11-09 | 1d? | 126.88d | 0.12d | start no earlier than 2002-01-04 | NG - Day shift |
| 23 | 2.1.7.5 | Follow-up for contract sign off 5 |  | 1d? | 2002-01-14 | 2002-01-14 | 22 | 2001-11-12 | 2001-11-12 | 1d? | 126.88d | 0.12d | start no earlier than 2002-01-05 | NG - Day shift |
| 24 | 2.1.7.6 | Follow-up for contract sign off 6 |  | 1d? | 2002-01-15 | 2002-01-15 | 23 | 2001-11-13 | 2001-11-13 | 1d? | 126.88d | 0.12d | start no earlier than 2002-01-07 | NG - Day shift |
| 25 | 2.1.7.7 | Follow-up for contract sign off 7 |  | 1d? | 2002-01-16 | 2002-01-16 | 24 | 2001-11-14 | 2001-11-14 | 1d? | 126.88d | 0d | start no earlier than 2002-01-08 | NG - Day shift |
| 26 | 2.1.8 | Contract signed off | milestone | 0d | 2002-01-16 | 2002-01-16 | 25 | 2001-11-14 | 2001-11-14 | 0d | 115d |  |  |  |

Notes:
- 1: This is the colour code for Summary tasks / This is the colour code for general tasks / This is the colour code for payment related tasks / This is the colour code for B & UI related tasks / This is the colour code for Branching out warnings !

| ID | WBS | Task | Type | Duration | Start | Finish | Predecessors | Baseline start | Baseline finish | Baseline duration | Total slack | Free slack | Constraint | Calendar |
| --- | --- | --- | --- | --- | --- | --- | --- | --- | --- | --- | --- | --- | --- | --- |
| 27 | 2.2 | **Concept note** |  | 9d? | 2002-01-08 | 2002-01-18 |  |  |  |  | 15d |  |  |  |
| 28 | 2.2.1 | Concept note - Running through the Client briefing checklist with the Client |  | 1d? | 2002-01-08 | 2002-01-08 | 11 | 2001-11-06 | 2001-11-06 | 1d? | 15d | 0d |  |  |
| 29 | 2.2.2 | Concept note - Preparation |  | 1d? | 2002-01-09 | 2002-01-09 | 28 | 2001-11-07 | 2001-11-07 | 1d? | 15d | 0d |  |  |
| 30 | 2.2.3 | Concept note - Internal review |  | 1d? | 2002-01-10 | 2002-01-10 | 29 | 2001-11-08 | 2001-11-08 | 1d? | 15d | 0d |  |  |
| 31 | 2.2.4 | Concept note - Incorporating modifications |  | 1d? | 2002-01-11 | 2002-01-11 | 30 | 2001-11-09 | 2001-11-09 | 1d? | 15d | 0d |  |  |
| 32 | 2.2.5 | Concept note - Internal review & approval |  | 1d? | 2002-01-14 | 2002-01-14 | 31 | 2001-11-12 | 2001-11-12 | 1d? | 15d | 0d |  |  |
| 33 | 2.2.6 | Concept note - Client review |  | 1d? | 2002-01-15 | 2002-01-15 | 32 | 2001-11-13 | 2001-11-13 | 1d? | 15d | 0d |  |  |
| 34 | 2.2.7 | Concept note - Incorporating Client modifications |  | 1d? | 2002-01-16 | 2002-01-16 | 33 | 2001-11-14 | 2001-11-14 | 1d? | 15d | 0d |  |  |
| 35 | 2.2.8 | Concept note - Internal review & approval |  | 1d? | 2002-01-17 | 2002-01-17 | 34 | 2001-11-15 | 2001-11-15 | 1d? | 15d | 0d |  |  |
| 36 | 2.2.9 | Concept note - Client review & approval |  | 1d? | 2002-01-18 | 2002-01-18 | 35 | 2001-11-16 | 2001-11-16 | 1d? | 15d | 0d |  |  |
| 37 | 2.2.10 | Concept note - Sign off | milestone | 0d | 2002-01-18 | 2002-01-18 | 36 | 2001-11-19 | 2001-11-19 | 1d? | 15d |  |  |  |
| 38 | 2.3 | **FE** |  | 11d? | 2002-01-08 | 2002-01-22 |  |  |  |  | 0.12d |  |  |  |
| 39 | 2.3.1 | FE - Preparation |  | 1d? | 2002-01-08 | 2002-01-08 | 11 | 2001-11-06 | 2001-11-06 | 1d? | 0.12d | 0d |  |  |
| 40 | 2.3.2 | FE - Internal review |  | 1d? | 2002-01-09 | 2002-01-09 | 39 | 2001-11-07 | 2001-11-07 | 1d? | 0.12d | 0d |  |  |
| 41 | 2.3.3 | FE - Incorporating modifications |  | 1d? | 2002-01-10 | 2002-01-10 | 40 | 2001-11-08 | 2001-11-08 | 1d? | 0.12d | 0d |  |  |
| 42 | 2.3.4 | FE - Internal review & approval |  | 1d? | 2002-01-11 | 2002-01-11 | 41 | 2001-11-09 | 2001-11-09 | 1d? | 0.12d | 0d |  |  |
| 43 | 2.3.5 | FE - Client review |  | 1d? | 2002-01-14 | 2002-01-14 | 42 | 2001-11-12 | 2001-11-12 | 1d? | 0.12d | 0d |  |  |
| 44 | 2.3.6 | FE - Incorporating Client modifications |  | 1d? | 2002-01-15 | 2002-01-15 | 43 | 2001-11-13 | 2001-11-13 | 1d? | 0.12d | 0d |  |  |
| 45 | 2.3.7 | FE - Internal review & approval |  | 1d? | 2002-01-16 | 2002-01-16 | 44 | 2001-11-14 | 2001-11-14 | 1d? | 0.12d | 0d |  |  |
| 46 | 2.3.8 | FE - Client review & approval |  | 1d? | 2002-01-17 | 2002-01-17 | 45 | 2001-11-15 | 2001-11-15 | 1d? | 0.12d | 0d |  |  |
| 47 | 2.3.9 | FE - Phase sign off | milestone | 0h | 2002-01-17 | 2002-01-17 | 46 | 2001-11-15 | 2001-11-15 | 0h | 0.12d | 0d |  |  |
| 48 | 2.3.10 | **FE - Follow-up for phase payment** |  | 4d? | 2002-01-17 | 2002-01-22 |  | 2001-11-16 | 2001-11-21 | 4d? | 122d |  |  | NG - Day shift |
| 49 | 2.3.10.1 | FE - Follow-up for phase payment 1 |  | 1d? | 2002-01-17 | 2002-01-18 | 47 | 2001-11-16 | 2001-11-16 | 1d? | 122d | 0d | start no earlier than 2002-01-01 | NG - Day shift |
| 50 | 2.3.10.2 | FE - Follow-up for phase payment 2 |  | 1d? | 2002-01-18 | 2002-01-19 | 49 | 2001-11-19 | 2001-11-19 | 1d? | 122d | 0d | start no earlier than 2002-01-02 | NG - Day shift |
| 51 | 2.3.10.3 | FE - Follow-up for phase payment 3 |  | 1d? | 2002-01-19 | 2002-01-21 | 50 | 2001-11-20 | 2001-11-20 | 1d? | 122d | 0d | start no earlier than 2002-01-03 | NG - Day shift |
| 52 | 2.3.10.4 | FE - Follow-up for phase payment 4 |  | 1d? | 2002-01-21 | 2002-01-22 | 51 | 2001-11-21 | 2001-11-21 | 1d? | 122d | 0d | start no earlier than 2002-01-04 | NG - Day shift |
| 53 | 2.3.11 | FE - Phase payment received | milestone | 0d | 2002-01-22 | 2002-01-22 | 52 | 2001-11-21 | 2001-11-21 | 0d | 111d |  |  |  |

| ID | WBS | Task | Type | Duration | Start | Finish | Predecessors | Baseline start | Baseline finish | Baseline duration | Total slack | Free slack |
| --- | --- | --- | --- | --- | --- | --- | --- | --- | --- | --- | --- | --- |
| 54 | 2.4 | **TP** |  | 1d? | 2002-01-18 | 2002-01-18 |  |  |  |  | 0.12d |  |
| 55 | 2.4.1 | TP - Preparation of the project template |  | 1d? | 2002-01-18 | 2002-01-18 | 47 | 2001-11-16 | 2001-11-16 | 1d? | 0.12d | 0d |
| 56 | 3 | **MODULE 1** |  | 93.88d? | 2002-01-01 | 2002-05-10 |  | 2001-10-29 | 2001-12-19 | 38d? | 15d |  |
| 57 | 3.1 | **M1 - TP** |  | 29.88d? | 2002-01-01 | 2002-02-11 |  |  |  |  | 15d |  |
| 58 | 3.1.1 | M1 - TP - Preparation of sketch |  | 1d? | 2002-01-21 | 2002-01-21 | 55 | 2001-10-29 | 2001-10-29 | 1d? | 1.12d | 0d |
| 59 | 3.1.2 | M1 - TP - Preparation of proto |  | 1d? | 2002-01-22 | 2002-01-22 | 58 | 2001-10-30 | 2001-10-30 | 1d? | 1.12d | 0d |
| 60 | 3.1.3 | M1 - TP - Review against sketches |  | 1d? | 2002-01-24 | 2002-01-24 | 59 | 2001-10-31 | 2001-10-31 | 1d? | 1.12d | 0d |
| 61 | 3.1.4 | M1 - TP - Incorporating modifications |  | 1d? | 2002-01-25 | 2002-01-25 | 60 | 2001-11-01 | 2001-11-01 | 1d? | 1.12d | 0d |
| 62 | 3.1.5 | M1 - TP - Testing by developer |  | 1d? | 2002-01-28 | 2002-01-28 | 61 | 2001-11-02 | 2001-11-02 | 1d? | 1.12d | 0d |
| 63 | 3.1.6 | M1 - TP - Developer bug fixing |  | 1d? | 2002-01-29 | 2002-01-29 | 62 | 2001-11-05 | 2001-11-05 | 1d? | 1.12d | 0d |
| 64 | 3.1.7 | M1 - TP - Testing by QC |  | 1d? | 2002-01-30 | 2002-01-30 | 63 | 2001-11-06 | 2001-11-06 | 1d? | 1.12d | 0d |
| 65 | 3.1.8 | M1 - TP - QC bug fixing |  | 1d? | 2002-01-31 | 2002-01-31 | 64 | 2001-11-07 | 2001-11-07 | 1d? | 1.12d | 0d |
| 66 | 3.1.9 | M1 - TP - Retesting by QC |  | 1d? | 2002-02-01 | 2002-02-01 | 65 | 2001-11-08 | 2001-11-08 | 1d? | 1.12d | 0d |
| 67 | 3.1.10 | Go To TP - Consolidation ! |  | 8h? | 2002-01-01 | 2002-01-02 |  |  |  |  | 125.88d |  |
| 68 | 3.1.11 | M1 - TP - Incorporating Client modifications |  | 1d? | 2002-02-08 | 2002-02-08 | 283 | 2001-11-12 | 2001-11-12 | 1d? | 0d |  |
| 69 | 3.1.12 | M1 - TP - Internal review & approval |  | 1d? | 2002-02-11 | 2002-02-11 | 68 | 2001-11-13 | 2001-11-13 | 1d? | 4.12d | 0d |
| 70 | 3.1.13 | Go To TP - Client changes consolidation ! |  | 8h? | 2002-01-01 | 2002-01-02 |  |  |  |  | 125.88d |  |
| 71 | 3.1.14 | M1 - TP - Complete | milestone | 0d | 2002-02-11 | 2002-02-11 | 69 | 2001-11-15 | 2001-11-15 | 1d? | 97d |  |
| 72 | 3.2 | **M1 - FS** |  | 31.88d? | 2002-01-01 | 2002-02-13 |  |  |  |  | 68.88d |  |
| 73 | 3.2.1 | M1 - FS - Preparation |  | 1d? | 2002-02-04 | 2002-02-04 | 66 | 2001-11-15 | 2001-11-15 | 1d? | 45d | 0d |
| 74 | 3.2.2 | M1 - FS - Internal review |  | 1d? | 2002-02-05 | 2002-02-05 | 73 | 2001-11-16 | 2001-11-16 | 1d? | 45d | 0d |
| 75 | 3.2.3 | M1 - FS - Incorporating modifications |  | 1d? | 2002-02-06 | 2002-02-06 | 74 | 2001-11-19 | 2001-11-19 | 1d? | 45d | 0d |
| 76 | 3.2.4 | M1 - FS - Internal review & approval |  | 1d? | 2002-02-07 | 2002-02-07 | 75 | 2001-11-20 | 2001-11-20 | 1d? | 45d | 0d |
| 77 | 3.2.5 | M1 - FS - Client review |  | 1d? | 2002-02-08 | 2002-02-08 | 76 | 2001-11-21 | 2001-11-21 | 1d? | 45d | 0d |
| 78 | 3.2.6 | M1 - FS - Incorporating Client modifications |  | 1d? | 2002-02-11 | 2002-02-11 | 77 | 2001-11-22 | 2001-11-22 | 1d? | 45d | 0d |
| 79 | 3.2.7 | M1 - FS - Internal review & approval |  | 1d? | 2002-02-12 | 2002-02-12 | 78 | 2001-11-23 | 2001-11-23 | 1d? | 45d | 0d |
| 80 | 3.2.8 | M1 - FS - Client review & approval |  | 1d? | 2002-02-13 | 2002-02-13 | 79 | 2001-11-26 | 2001-11-26 | 1d? | 45d | 0d |
| 81 | 3.2.9 | Go To FS - Phase integration ! |  | 8h? | 2002-01-01 | 2002-01-02 |  |  |  |  | 125.88d |  |
| 82 | 3.2.10 | M1 - FS - Complete | milestone | 0d | 2002-02-13 | 2002-02-13 | 80 | 2001-11-26 | 2001-11-26 | 0d | 95d |  |

| ID | WBS | Task | Type | Duration | Start | Finish | Predecessors | Baseline start | Baseline finish | Baseline duration | Total slack | Free slack |
| --- | --- | --- | --- | --- | --- | --- | --- | --- | --- | --- | --- | --- |
| 83 | 3.3 | **M1 - GP** |  | 77.88d? | 2002-01-01 | 2002-04-18 |  |  |  |  | 49d |  |
| 84 | 3.3.1 | M1 - GP - Preparation |  | 1d? | 2002-04-02 | 2002-04-02 | 277 | 2001-10-29 | 2001-10-29 | 1d? | 0d |  |
| 85 | 3.3.2 | M1 - GP - Internal review by B & UI |  | 1d? | 2002-04-03 | 2002-04-03 | 84 | 2001-10-30 | 2001-10-30 | 1d? | 0d |  |
| 86 | 3.3.3 | M1 - GP - Internal review by Development |  | 1d? | 2002-04-04 | 2002-04-04 | 85 | 2001-10-31 | 2001-10-31 | 1d? | 0d |  |
| 87 | 3.3.4 | M1 - GP - Incorporating modifications |  | 1d? | 2002-04-05 | 2002-04-05 | 86 | 2001-11-01 | 2001-11-01 | 1d? | 0d |  |
| 88 | 3.3.5 | M1 - GP - Unit testing by B & UI |  | 1d? | 2002-04-08 | 2002-04-08 | 87 | 2001-11-02 | 2001-11-02 | 1d? | 0d |  |
| 89 | 3.3.6 | M1 - GP - B & UI bug fixing |  | 1d? | 2002-04-09 | 2002-04-09 | 88 | 2001-11-05 | 2001-11-05 | 1d? | 0d |  |
| 90 | 3.3.7 | M1 - GP - Testing by QC |  | 1d? | 2002-04-10 | 2002-04-10 | 89 | 2001-11-06 | 2001-11-06 | 1d? | 0d |  |
| 91 | 3.3.8 | M1 - GP - QC Bug fixing |  | 1d? | 2002-04-11 | 2002-04-11 | 90 | 2001-11-07 | 2001-11-07 | 1d? | 0d |  |
| 92 | 3.3.9 | M1 - GP - Retesting by QC |  | 1d? | 2002-04-12 | 2002-04-12 | 91 | 2001-11-08 | 2001-11-08 | 1d? | 0d |  |
| 93 | 3.3.10 | Go To GP - Consolidation ! |  | 8h? | 2002-01-01 | 2002-01-02 |  |  |  |  | 125.88d |  |
| 94 | 3.3.11 | M1 - GP - Incorporating Client modifications |  | 1d? | 2002-04-17 | 2002-04-17 | 316 | 2001-11-12 | 2001-11-12 | 1d? | 0.12d | 0d |
| 95 | 3.3.12 | M1 - GP - Internal review & approval |  | 1d? | 2002-04-18 | 2002-04-18 | 94 | 2001-11-13 | 2001-11-13 | 1d? | 0.12d | 0d |
| 96 | 3.3.13 | Go To GP - Client changes consolidation ! |  | 8h? | 2002-01-01 | 2002-01-02 |  |  |  |  | 125.88d |  |
| 97 | 3.3.14 | M1 - GP - Complete | milestone | 0d | 2002-04-18 | 2002-04-18 | 95 | 2001-11-14 | 2001-11-14 | 0d | 49d |  |
| 98 | 3.4 | **M1 - TS** |  | 4d? | 2002-03-01 | 2002-03-06 |  |  |  |  | 34d |  |
| 99 | 3.4.1 | M1 - TS - Preparation |  | 1d? | 2002-03-01 | 2002-03-01 | 80, 310, 224 | 2001-11-27 | 2001-11-27 | 1d? | 34d | 0d |
| 100 | 3.4.2 | M1 - TS - Internal review |  | 1d? | 2002-03-04 | 2002-03-04 | 99 | 2001-11-28 | 2001-11-28 | 1d? | 34d | 0d |
| 101 | 3.4.3 | M1 - TS - Incorporating modifications |  | 1d? | 2002-03-05 | 2002-03-05 | 100 | 2001-11-29 | 2001-11-29 | 1d? | 34d | 0d |
| 102 | 3.4.4 | M1 - TS - Internal review & approval |  | 1d? | 2002-03-06 | 2002-03-06 | 101 | 2001-11-30 | 2001-11-30 | 1d? | 34d | 0d |
| 103 | 3.4.5 | M1 - TS - Complete | milestone | 0d | 2002-03-06 | 2002-03-06 | 102 | 2001-11-30 | 2001-11-30 | 0d | 80d |  |
| 104 | 3.5 | **M1 - Coding** |  | 7d? | 2002-04-24 | 2002-05-02 |  |  |  |  | 0d |  |
| 105 | 3.5.1 | M1 - Coding - Coding by developers |  | 1d? | 2002-04-24 | 2002-04-24 | 102, 321 | 2001-12-03 | 2001-12-03 | 1d? | 0d |  |
| 106 | 3.5.2 | M1 - Coding - Code review by developers |  | 1d? | 2002-04-25 | 2002-04-25 | 105 | 2001-12-04 | 2001-12-04 | 1d? | 0d |  |
| 107 | 3.5.3 | M1 - Coding - Developer bug fixing |  | 1d? | 2002-04-26 | 2002-04-26 | 106 | 2001-12-05 | 2001-12-05 | 1d? | 0d |  |
| 108 | 3.5.4 | M1 - Coding - Code Review by peers |  | 1d? | 2002-04-29 | 2002-04-29 | 107 | 2001-12-06 | 2001-12-06 | 1d? | 0d |  |
| 109 | 3.5.5 | M1 - Coding - Peer bug fixing |  | 1d? | 2002-04-30 | 2002-04-30 | 108 | 2001-12-07 | 2001-12-07 | 1d? | 0d |  |
| 110 | 3.5.6 | M1 - Coding - Code walk-through by DM |  | 1d? | 2002-05-01 | 2002-05-01 | 109 | 2001-12-10 | 2001-12-10 | 1d? | 0d |  |
| 111 | 3.5.7 | M1 - Coding - DM bug fixing |  | 1d? | 2002-05-02 | 2002-05-02 | 110 | 2001-12-11 | 2001-12-11 | 1d? | 0d |  |
| 112 | 3.5.8 | M1 - Coding - Complete | milestone | 0d | 2002-05-02 | 2002-05-02 | 111 | 2001-12-11 | 2001-12-11 | 0d | 39d |  |

| ID | WBS | Task | Type | Duration | Start | Finish | Predecessors | Baseline start | Baseline finish | Baseline duration | Total slack | Free slack |
| --- | --- | --- | --- | --- | --- | --- | --- | --- | --- | --- | --- | --- |
| 113 | 3.6 | **M1 - Unit testing** |  | 3d? | 2002-05-03 | 2002-05-07 |  |  |  |  | 0d |  |
| 114 | 3.6.1 | M1 - Unit testing - By QC |  | 1d? | 2002-05-03 | 2002-05-03 | 111 | 2001-12-12 | 2001-12-12 | 1d? | 0d |  |
| 115 | 3.6.2 | M1 - Unit testing - Bug fixing by Development |  | 1d? | 2002-05-06 | 2002-05-06 | 114 | 2001-12-13 | 2001-12-13 | 1d? | 0d |  |
| 116 | 3.6.3 | M1 - Unit testing - Retesting by QC |  | 1d? | 2002-05-07 | 2002-05-07 | 115 | 2001-12-14 | 2001-12-14 | 1d? | 0d |  |
| 117 | 3.6.4 | M1 - Unit testing - Complete | milestone | 0d | 2002-05-07 | 2002-05-07 | 116 | 2001-12-14 | 2001-12-14 | 0d | 36d |  |
| 118 | 3.7 | **M1 - Functionality testing** |  | 3d? | 2002-05-08 | 2002-05-10 |  |  |  |  | 0d |  |
| 119 | 3.7.1 | M1 - Functionality testing - By QC |  | 1d? | 2002-05-08 | 2002-05-08 | 116 | 2001-12-17 | 2001-12-17 | 1d? | 0d |  |
| 120 | 3.7.2 | M1 - Functionality testing - Bug fixing by Development |  | 1d? | 2002-05-09 | 2002-05-09 | 119 | 2001-12-18 | 2001-12-18 | 1d? | 0d |  |
| 121 | 3.7.3 | M1 - Functionality testing - Retesting by QC |  | 1d? | 2002-05-10 | 2002-05-10 | 120 | 2001-12-19 | 2001-12-19 | 1d? | 0d |  |
| 122 | 3.7.4 | M1 - Functionality testing - Complete | milestone | 0d | 2002-05-10 | 2002-05-10 | 121 | 2001-12-19 | 2001-12-19 | 0d | 33d |  |
| 123 | 4 | **MODULE 2** |  | 93.88d? | 2002-01-01 | 2002-05-10 |  | 2001-10-29 | 2001-12-19 | 38d? | 14d |  |
| 124 | 4.1 | **M2 - TP** |  | 29.88d? | 2002-01-01 | 2002-02-11 |  |  |  |  | 14d |  |
| 125 | 4.1.1 | M2 - TP - Preparation of sketch |  | 1d? | 2002-01-21 | 2002-01-21 | 55 | 2001-10-29 | 2001-10-29 | 1d? | 0.12d | 0d |
| 126 | 4.1.2 | M2 - TP - Preparation of proto |  | 1d? | 2002-01-22 | 2002-01-22 | 125 | 2001-10-30 | 2001-10-30 | 1d? | 0.12d | 0d |
| 127 | 4.1.3 | M2 - TP - Review against sketches |  | 1d? | 2002-01-24 | 2002-01-24 | 126 | 2001-10-31 | 2001-10-31 | 1d? | 0.12d | 0d |
| 128 | 4.1.4 | M2 - TP - Incorporating modifications |  | 1d? | 2002-01-25 | 2002-01-25 | 127 | 2001-11-01 | 2001-11-01 | 1d? | 0.12d | 0d |
| 129 | 4.1.5 | M2 - TP - Testing by developer |  | 1d? | 2002-01-28 | 2002-01-28 | 128 | 2001-11-02 | 2001-11-02 | 1d? | 0.12d | 0d |
| 130 | 4.1.6 | M2 - TP - Developer bug fixing |  | 1d? | 2002-01-30 | 2002-01-30 | 129 | 2001-11-05 | 2001-11-05 | 1d? | 0.12d | 0d |
| 131 | 4.1.7 | M2 - TP - Testing by QC |  | 1d? | 2002-01-31 | 2002-01-31 | 130 | 2001-11-06 | 2001-11-06 | 1d? | 0.12d | 0d |
| 132 | 4.1.8 | M2 - TP - QC bug fixing |  | 1d? | 2002-02-01 | 2002-02-01 | 131 | 2001-11-07 | 2001-11-07 | 1d? | 0.12d | 0d |
| 133 | 4.1.9 | M2 - TP - Retesting by QC |  | 1d? | 2002-02-04 | 2002-02-04 | 132 | 2001-11-08 | 2001-11-08 | 1d? | 0.12d | 0d |
| 134 | 4.1.10 | Go To TP - Consolidation ! |  | 8h? | 2002-01-01 | 2002-01-02 |  |  |  |  | 125.88d |  |
| 135 | 4.1.11 | M2 - TP - Incorporating Client modifications |  | 1d? | 2002-02-08 | 2002-02-08 | 283 | 2001-11-12 | 2001-11-12 | 1d? | 0d |  |
| 136 | 4.1.12 | M2 - TP - Internal review & approval |  | 1d? | 2002-02-11 | 2002-02-11 | 135 | 2001-11-13 | 2001-11-13 | 1d? | 4.12d | 0d |
| 137 | 4.1.13 | Go To TP - Client changes consolidation ! |  | 8h? | 2002-01-01 | 2002-01-02 |  |  |  |  | 125.88d |  |
| 138 | 4.1.14 | M2 - TP - Complete | milestone | 0d | 2002-02-11 | 2002-02-11 | 136 | 2001-11-14 | 2001-11-14 | 0d | 97d |  |

| ID | WBS | Task | Type | Duration | Start | Finish | Predecessors | Baseline start | Baseline finish | Baseline duration | Total slack | Free slack |
| --- | --- | --- | --- | --- | --- | --- | --- | --- | --- | --- | --- | --- |
| 139 | 4.2 | **M2 - FS** |  | 32.88d? | 2002-01-01 | 2002-02-14 |  |  |  |  | 68.88d |  |
| 140 | 4.2.1 | M2 - FS - Preparation |  | 1d? | 2002-02-05 | 2002-02-05 | 133 | 2001-11-15 | 2001-11-15 | 1d? | 44d | 0d |
| 141 | 4.2.2 | M2 - FS - Internal review |  | 1d? | 2002-02-06 | 2002-02-06 | 140 | 2001-11-16 | 2001-11-16 | 1d? | 44d | 0d |
| 142 | 4.2.3 | M2 - FS - Incorporating modifications |  | 1d? | 2002-02-07 | 2002-02-07 | 141 | 2001-11-19 | 2001-11-19 | 1d? | 44d | 0d |
| 143 | 4.2.4 | M2 - FS - Internal review & approval |  | 1d? | 2002-02-08 | 2002-02-08 | 142 | 2001-11-20 | 2001-11-20 | 1d? | 44d | 0d |
| 144 | 4.2.5 | M2 - FS - Client review |  | 1d? | 2002-02-11 | 2002-02-11 | 143 | 2001-11-21 | 2001-11-21 | 1d? | 44d | 0d |
| 145 | 4.2.6 | M2 - FS - Incorporating Client modifications |  | 1d? | 2002-02-12 | 2002-02-12 | 144 | 2001-11-22 | 2001-11-22 | 1d? | 44d | 0d |
| 146 | 4.2.7 | M2 - FS - Internal review & approval |  | 1d? | 2002-02-13 | 2002-02-13 | 145 | 2001-11-23 | 2001-11-23 | 1d? | 44d | 0d |
| 147 | 4.2.8 | M2 - FS - Client review & approval |  | 1d? | 2002-02-14 | 2002-02-14 | 146 | 2001-11-26 | 2001-11-26 | 1d? | 44d | 0d |
| 148 | 4.2.9 | Go To FS - Phase integration ! |  | 8h? | 2002-01-01 | 2002-01-02 |  |  |  |  | 125.88d |  |
| 149 | 4.2.10 | M2 - FS - Complete | milestone | 0d | 2002-02-14 | 2002-02-14 | 147 | 2001-11-26 | 2001-11-26 | 0d | 94d |  |
| 150 | 4.3 | **M2 - GP** |  | 77.88d? | 2002-01-01 | 2002-04-18 |  |  |  |  | 49d |  |
| 151 | 4.3.1 | M2 - GP - Preparation |  | 1d? | 2002-04-02 | 2002-04-02 | 277 | 2001-10-29 | 2001-10-29 | 1d? | 0d |  |
| 152 | 4.3.2 | M2 - GP - Internal review by B & UI |  | 1d? | 2002-04-03 | 2002-04-03 | 151 | 2001-10-30 | 2001-10-30 | 1d? | 0d |  |
| 153 | 4.3.3 | M2 - GP - Internal review by Development |  | 1d? | 2002-04-04 | 2002-04-04 | 152 | 2001-10-31 | 2001-10-31 | 1d? | 0d |  |
| 154 | 4.3.4 | M2 - GP - Incorporating modifications |  | 1d? | 2002-04-05 | 2002-04-05 | 153 | 2001-11-01 | 2001-11-01 | 1d? | 0d |  |
| 155 | 4.3.5 | M2 - GP - Unit testing by B & UI |  | 1d? | 2002-04-08 | 2002-04-08 | 154 | 2001-11-02 | 2001-11-02 | 1d? | 0d |  |
| 156 | 4.3.6 | M2 - GP - B & UI bug fixing |  | 1d? | 2002-04-09 | 2002-04-09 | 155 | 2001-11-05 | 2001-11-05 | 1d? | 0d |  |
| 157 | 4.3.7 | M2 - GP - Testing by QC |  | 1d? | 2002-04-10 | 2002-04-10 | 156 | 2001-11-06 | 2001-11-06 | 1d? | 0d |  |
| 158 | 4.3.8 | M2 - GP - QC Bug fixing |  | 1d? | 2002-04-11 | 2002-04-11 | 157 | 2001-11-07 | 2001-11-07 | 1d? | 0d |  |
| 159 | 4.3.9 | M2 - GP - Retesting by QC |  | 1d? | 2002-04-12 | 2002-04-12 | 158 | 2001-11-08 | 2001-11-08 | 1d? | 0d |  |
| 160 | 4.3.10 | Go To GP - Consolidation ! |  | 8h? | 2002-01-01 | 2002-01-02 |  |  |  |  | 125.88d |  |
| 161 | 4.3.11 | M2 - GP - Incorporating Client modifications |  | 1d? | 2002-04-17 | 2002-04-17 | 316 | 2001-11-12 | 2001-11-12 | 1d? | 0.12d | 0d |
| 162 | 4.3.12 | M2 - GP - Internal review & approval |  | 1d? | 2002-04-18 | 2002-04-18 | 161 | 2001-11-13 | 2001-11-13 | 1d? | 0.12d | 0d |
| 163 | 4.3.13 | Go To GP - Client changes consolidation ! |  | 8h? | 2002-01-01 | 2002-01-02 |  |  |  |  | 125.88d |  |
| 164 | 4.3.14 | M2 - GP - Complete | milestone | 0d | 2002-04-18 | 2002-04-18 | 162 | 2001-11-14 | 2001-11-14 | 0d | 49d |  |

| ID | WBS | Task | Type | Duration | Start | Finish | Predecessors | Baseline start | Baseline finish | Baseline duration | Total slack | Free slack |
| --- | --- | --- | --- | --- | --- | --- | --- | --- | --- | --- | --- | --- |
| 165 | 4.4 | **M2 - TS** |  | 4d? | 2002-03-01 | 2002-03-06 |  |  |  |  | 34d |  |
| 166 | 4.4.1 | M2 - TS - Preparation |  | 1d? | 2002-03-01 | 2002-03-01 | 147, 310, 224 | 2001-11-27 | 2001-11-27 | 1d? | 34d | 0d |
| 167 | 4.4.2 | M2 - TS - Internal review |  | 1d? | 2002-03-04 | 2002-03-04 | 166 | 2001-11-28 | 2001-11-28 | 1d? | 34d | 0d |
| 168 | 4.4.3 | M2 - TS - Incorporating modifications |  | 1d? | 2002-03-05 | 2002-03-05 | 167 | 2001-11-29 | 2001-11-29 | 1d? | 34d | 0d |
| 169 | 4.4.4 | M2 - TS - Internal review & approval |  | 1d? | 2002-03-06 | 2002-03-06 | 168 | 2001-11-30 | 2001-11-30 | 1d? | 34d | 0d |
| 170 | 4.4.5 | M2 - TS - Complete | milestone | 0d | 2002-03-06 | 2002-03-06 | 169 | 2001-11-30 | 2001-11-30 | 0d | 80d |  |
| 171 | 4.5 | **M2 - Coding** |  | 7d? | 2002-04-24 | 2002-05-02 |  |  |  |  | 0d |  |
| 172 | 4.5.1 | M2 - Coding - Coding by developers |  | 1d? | 2002-04-24 | 2002-04-24 | 169, 321 | 2001-12-03 | 2001-12-03 | 1d? | 0d |  |
| 173 | 4.5.2 | M2 - Coding - Code review by developers |  | 1d? | 2002-04-25 | 2002-04-25 | 172 | 2001-12-04 | 2001-12-04 | 1d? | 0d |  |
| 174 | 4.5.3 | M2 - Coding - Developer bug fixing |  | 1d? | 2002-04-26 | 2002-04-26 | 173 | 2001-12-05 | 2001-12-05 | 1d? | 0d |  |
| 175 | 4.5.4 | M2 - Coding - Code Review by peers |  | 1d? | 2002-04-29 | 2002-04-29 | 174 | 2001-12-06 | 2001-12-06 | 1d? | 0d |  |
| 176 | 4.5.5 | M2 - Coding - Peer bug fixing |  | 1d? | 2002-04-30 | 2002-04-30 | 175 | 2001-12-07 | 2001-12-07 | 1d? | 0d |  |
| 177 | 4.5.6 | M2 - Coding - Code walk-through by DM |  | 1d? | 2002-05-01 | 2002-05-01 | 176 | 2001-12-10 | 2001-12-10 | 1d? | 0d |  |
| 178 | 4.5.7 | M2 - Coding - DM bug fixing |  | 1d? | 2002-05-02 | 2002-05-02 | 177 | 2001-12-11 | 2001-12-11 | 1d? | 0d |  |
| 179 | 4.5.8 | M2 - Coding - Complete | milestone | 0d | 2002-05-02 | 2002-05-02 | 178 | 2001-12-11 | 2001-12-11 | 0d | 39d |  |
| 180 | 4.6 | **M2 - Unit testing** |  | 3d? | 2002-05-03 | 2002-05-07 |  |  |  |  | 0d |  |
| 181 | 4.6.1 | M2 - Unit testing - By QC |  | 1d? | 2002-05-03 | 2002-05-03 | 178 | 2001-12-12 | 2001-12-12 | 1d? | 0d |  |
| 182 | 4.6.2 | M2 - Unit testing - Bug fixing by Development |  | 1d? | 2002-05-06 | 2002-05-06 | 181 | 2001-12-13 | 2001-12-13 | 1d? | 0d |  |
| 183 | 4.6.3 | M2 - Unit testing - Retesting by QC |  | 1d? | 2002-05-07 | 2002-05-07 | 182 | 2001-12-14 | 2001-12-14 | 1d? | 0d |  |
| 184 | 4.6.4 | M2 - Unit testing - Complete | milestone | 0d | 2002-05-07 | 2002-05-07 | 183 | 2001-12-14 | 2001-12-14 | 0d | 36d |  |
| 185 | 4.7 | **M2 - Functionality testing** |  | 3d? | 2002-05-08 | 2002-05-10 |  |  |  |  | 0d |  |
| 186 | 4.7.1 | M2 - Functionality testing - By QC |  | 1d? | 2002-05-08 | 2002-05-08 | 183 | 2001-12-17 | 2001-12-17 | 1d? | 0d |  |
| 187 | 4.7.2 | M2 - Functionality testing - Bug fixing by Development |  | 1d? | 2002-05-09 | 2002-05-09 | 186 | 2001-12-18 | 2001-12-18 | 1d? | 0d |  |
| 188 | 4.7.3 | M2 - Functionality testing - Retesting by QC |  | 1d? | 2002-05-10 | 2002-05-10 | 187 | 2001-12-19 | 2001-12-19 | 1d? | 0d |  |
| 189 | 4.7.4 | M2 - Functionality testing - Complete | milestone | 0d | 2002-05-10 | 2002-05-10 | 188 | 2001-12-19 | 2001-12-19 | 0d | 33d |  |

| ID | WBS | Task | Type | Duration | Start | Finish | Predecessors | Baseline start | Baseline finish | Baseline duration | Total slack | Free slack | Constraint | Calendar |
| --- | --- | --- | --- | --- | --- | --- | --- | --- | --- | --- | --- | --- | --- | --- |
| 190 | 53 | **PHASE INTEGRATION** |  | 93.88d? | 2002-01-01 | 2002-05-10 |  | 2001-10-29 | 2001-10-29 | 0d | 25d |  |  |  |
| 191 | 53.1 | TP - Consolidation | milestone | 0d | 2002-02-04 | 2002-02-04 | 66, 133 | 2001-10-29 | 2001-10-29 | 0d | 0.12d | 0d |  |  |
| 192 | 53.2 | Go To TP - Client Review ! |  | 8h? | 2002-01-01 | 2002-01-02 |  |  |  |  | 125.88d |  |  |  |
| 193 | 53.3 | TP - Client changes consolidation | milestone | 0d | 2002-02-11 | 2002-02-11 | 69, 136 |  |  |  | 4.12d | 0d |  |  |
| 194 | 53.4 | Go To TP - Client review & approval ! |  | 8h? | 2002-01-01 | 2002-01-02 |  |  |  |  | 125.88d |  |  |  |
| 195 | 53.5 | FS - phase integration | milestone | 0d | 2002-02-14 | 2002-02-14 | 80, 147 | 2001-10-29 | 2001-10-29 | 0d | 91d | 0d |  |  |
| 196 | 53.6 | Go To FS - Phase sign off ! |  | 8h? | 2002-01-01 | 2002-01-02 |  |  |  |  | 125.88d |  |  |  |
| 197 | 53.7 | GP - Consolidation | milestone | 0d | 2002-04-12 | 2002-04-12 | 92, 159 |  |  |  | 0d |  |  |  |
| 198 | 53.8 | Go To GP - Client review ! |  | 8h? | 2002-01-01 | 2002-01-02 |  |  |  |  | 125.88d |  |  |  |
| 199 | 53.9 | GP - Client changes consolidation | milestone | 0d | 2002-04-18 | 2002-04-18 | 95, 162 | 2001-10-29 | 2001-10-29 | 0d | 0.12d | 0d |  |  |
| 200 | 53.10 | Go To GP - Client review & approval ! |  | 8h? | 2002-01-01 | 2002-01-02 |  |  |  |  | 125.88d |  |  |  |
| 201 | 53.11 | TS - phase integration | milestone | 0d | 2002-03-06 | 2002-03-06 | 169, 102 | 2001-10-29 | 2001-10-29 | 0d | 80d |  |  |  |
| 202 | 53.12 | Coding - phase integration | milestone | 0d | 2002-05-02 | 2002-05-02 | 178, 111 | 2001-10-29 | 2001-10-29 | 0d | 39d |  |  |  |
| 203 | 53.13 | Unit testing - phase integration | milestone | 0d | 2002-05-07 | 2002-05-07 | 116, 183 | 2001-10-29 | 2001-10-29 | 0d | 36d |  |  |  |
| 204 | 53.14 | Functionality testing - phase integration | milestone | 0d | 2002-05-10 | 2002-05-10 | 121, 188 | 2001-10-29 | 2001-10-29 | 0d | 0d |  |  |  |
| 205 | 54 | **GENERAL TASKS (Contd…)** |  | 126.88d? | 2002-01-01 | 2002-06-26 |  | 2001-10-29 | 2002-02-13 | 78d? | 0d |  |  |  |
| 206 | 54.1 | **Content** |  | 42.88d? | 2002-01-01 | 2002-02-28 |  |  |  |  | 63d |  |  |  |
| 207 | 54.1.1 | **Content - Procurement / Creation** |  | 3d? | 2002-02-08 | 2002-02-13 |  |  |  |  | 37.12d |  |  | NG - Day shift |
| 208 | 54.1.1.1 | Content - Procurement / Creation 1 |  | 1d? | 2002-02-08 | 2002-02-11 | 68, 135 |  |  |  | 37.12d | 0d | start no earlier than 2002-01-01 | NG - Day shift |
| 209 | 54.1.1.2 | Content - Procurement / Creation 2 |  | 1d? | 2002-02-11 | 2002-02-12 | 208 |  |  |  | 37.12d | 0d | start no earlier than 2002-01-02 | NG - Day shift |
| 210 | 54.1.1.3 | Content - Procurement / Creation 3 |  | 1d? | 2002-02-12 | 2002-02-13 | 209 |  |  |  | 37.12d | 0d | start no earlier than 2002-01-03 | NG - Day shift |
| 211 | 54.1.2 | Content - Client discussion |  | 1d? | 2002-02-14 | 2002-02-14 | 210 | 2001-11-15 | 2001-11-15 | 1d? | 33.12d | 0d |  |  |
| 212 | 54.1.3 | **Content - Information gathering** |  | 7d? | 2002-02-14 | 2002-02-22 |  |  |  |  | 37.12d |  |  | NG - Day shift |
| 213 | 54.1.3.1 | Content - Information gathering 1 |  | 1d? | 2002-02-14 | 2002-02-15 | 211 |  |  |  | 37.12d | 0d | start no earlier than 2002-01-01 | NG - Day shift |
| 214 | 54.1.3.2 | Content - Information gathering 2 |  | 1d? | 2002-02-15 | 2002-02-16 | 213 |  |  |  | 37.12d | 0d | start no earlier than 2002-01-02 | NG - Day shift |
| 215 | 54.1.3.3 | Content - Information gathering 3 |  | 1d? | 2002-02-16 | 2002-02-18 | 214 |  |  |  | 37.12d | 0d | start no earlier than 2002-01-03 | NG - Day shift |
| 216 | 54.1.3.4 | Content - Information gathering 4 |  | 1d? | 2002-02-18 | 2002-02-19 | 215 |  |  |  | 37.12d | 0d | start no earlier than 2002-01-04 | NG - Day shift |
| 217 | 54.1.3.5 | Content - Information gathering 5 |  | 1d? | 2002-02-19 | 2002-02-20 | 216 |  |  |  | 37.12d | 0d | start no earlier than 2002-01-05 | NG - Day shift |
| 218 | 54.1.3.6 | Content - Information gathering 6 |  | 1d? | 2002-02-20 | 2002-02-21 | 217 |  |  |  | 37.12d | 0d | start no earlier than 2002-01-07 | NG - Day shift |
| 219 | 54.1.3.7 | Content - Information gathering 7 |  | 1d? | 2002-02-21 | 2002-02-22 | 218 |  |  |  | 37.12d | 0d | start no earlier than 2002-01-08 | NG - Day shift |
| 220 | 54.1.4 | Content - Copywriting |  | 1d? | 2002-02-25 | 2002-02-25 | 219 | 2001-11-27 | 2001-11-27 | 1d? | 34d | 0d |  |  |
| 221 | 54.1.5 | Content - Client review |  | 1d? | 2002-02-26 | 2002-02-26 | 220 | 2001-11-28 | 2001-11-28 | 1d? | 34d | 0d |  |  |
| 222 | 54.1.6 | Content - Incorporating Client modifications |  | 1d? | 2002-02-27 | 2002-02-27 | 221 | 2001-11-29 | 2001-11-29 | 1d? | 34d | 0d |  |  |
| 223 | 54.1.7 | Content - Client review & approval |  | 1d? | 2002-02-28 | 2002-02-28 | 222 | 2001-11-30 | 2001-11-30 | 1d? | 34d | 0d |  |  |
| 224 | 54.1.8 | Content - Sign off | milestone | 0d | 2002-02-28 | 2002-02-28 | 223 | 2001-12-03 | 2001-12-03 | 1d? | 34d | 0d |  |  |
| 225 | 54.1.9 | Go To DB - Preparation ! |  | 8h? | 2002-01-01 | 2002-01-02 |  |  |  |  | 125.88d |  |  |  |

| ID | WBS | Task | Type | Duration | Start | Finish | Predecessors | Baseline start | Baseline finish | Baseline duration | Total slack |
| --- | --- | --- | --- | --- | --- | --- | --- | --- | --- | --- | --- |
| 226 | 54.2 | **Visualization** |  | 8d? | 2002-02-11 | 2002-02-20 |  |  |  |  | 0d |
| 227 | 54.2.1 | Visualization - Preparation of the storyboard |  | 1d? | 2002-02-11 | 2002-02-11 | 68, 135, 37 | 2001-11-20 | 2001-11-20 | 1d? | 0d |
| 228 | 54.2.2 | Visualization - Internal review |  | 1d? | 2002-02-12 | 2002-02-12 | 227 | 2001-11-21 | 2001-11-21 | 1d? | 0d |
| 229 | 54.2.3 | Visualization - Incorporating modifications |  | 1d? | 2002-02-13 | 2002-02-13 | 228 | 2001-11-22 | 2001-11-22 | 1d? | 0d |
| 230 | 54.2.4 | Visualization - Internal review & approval |  | 1d? | 2002-02-14 | 2002-02-14 | 229 | 2001-11-23 | 2001-11-23 | 1d? | 0d |
| 231 | 54.2.5 | Visualization - Client review |  | 1d? | 2002-02-15 | 2002-02-15 | 230 | 2001-11-26 | 2001-11-26 | 1d? | 0d |
| 232 | 54.2.6 | Visualization - Incorporating Client modifications |  | 1d? | 2002-02-18 | 2002-02-18 | 231 | 2001-11-27 | 2001-11-27 | 1d? | 0d |
| 233 | 54.2.7 | Visualization - Internal review & approval |  | 1d? | 2002-02-19 | 2002-02-19 | 232 | 2001-11-28 | 2001-11-28 | 1d? | 0d |
| 234 | 54.2.8 | Visualization - Client review & approval |  | 1d? | 2002-02-20 | 2002-02-20 | 233 | 2001-11-29 | 2001-11-29 | 1d? | 0d |
| 235 | 54.2.9 | Visualization - Sign off | milestone | 0d | 2002-02-20 | 2002-02-20 | 234 | 2001-11-30 | 2001-11-30 | 1d? | 0d |
| 236 | 54.3 | **GS** |  | 8d? | 2002-02-21 | 2002-03-04 |  |  |  |  | 0d |
| 237 | 54.3.1 | GS - Preparation |  | 1d? | 2002-02-21 | 2002-02-21 | 288, 235 | 2001-12-03 | 2001-12-03 | 1d? | 0d |
| 238 | 54.3.2 | GS - Internal review |  | 1d? | 2002-02-22 | 2002-02-22 | 237 | 2001-12-04 | 2001-12-04 | 1d? | 0d |
| 239 | 54.3.3 | GS - Incorporating modifications |  | 1d? | 2002-02-25 | 2002-02-25 | 238 | 2001-12-05 | 2001-12-05 | 1d? | 0d |
| 240 | 54.3.4 | GS - Internal review & approval |  | 1d? | 2002-02-26 | 2002-02-26 | 239 | 2001-12-06 | 2001-12-06 | 1d? | 0d |
| 241 | 54.3.5 | GS - Client review |  | 1d? | 2002-02-27 | 2002-02-27 | 240 | 2001-12-07 | 2001-12-07 | 1d? | 0d |
| 242 | 54.3.6 | GS - Incorporating Client modifications |  | 1d? | 2002-02-28 | 2002-02-28 | 241 | 2001-12-10 | 2001-12-10 | 1d? | 0d |
| 243 | 54.3.7 | GS - Internal review & approval |  | 1d? | 2002-03-01 | 2002-03-01 | 242 | 2001-12-11 | 2001-12-11 | 1d? | 0d |
| 244 | 54.3.8 | GS - Client review & approval |  | 1d? | 2002-03-04 | 2002-03-04 | 243 | 2001-12-12 | 2001-12-12 | 1d? | 0d |
| 245 | 54.3.9 | GS - Sign off | milestone | 0d | 2002-03-04 | 2002-03-04 | 244 | 2001-12-13 | 2001-12-13 | 1d? | 0d |
| 246 | 54.4 | **GT** |  | 64.88d? | 2002-01-01 | 2002-04-01 |  |  |  |  | 44.88d |
| 247 | 54.4.1 | GT - General orientation by the core B & UI team to the rest of the B & UI team |  | 1d? | 2002-03-05 | 2002-03-05 | 245 | 2001-12-14 | 2001-12-14 | 1d? | 0d |
| 248 | 54.4.2 | GT - Orientation of the B & UI team to the TP by the Development DM |  | 1d? | 2002-03-06 | 2002-03-06 | 247 | 2001-12-17 | 2001-12-17 | 1d? | 0d |
| 249 | 54.4.3 | GT - HP - Creation of Template Designs |  | 1d? | 2002-03-07 | 2002-03-07 | 248 | 2001-12-18 | 2001-12-18 | 1d? | 0d |
| 250 | 54.4.4 | GT - HP - Internal Review by B & UI |  | 1d? | 2002-03-08 | 2002-03-08 | 249 | 2001-12-19 | 2001-12-19 | 1d? | 0d |
| 251 | 54.4.5 | GT - HP - Internal review by Development |  | 1d? | 2002-03-11 | 2002-03-11 | 250 | 2001-12-20 | 2001-12-20 | 1d? | 0d |
| 252 | 54.4.6 | GT - HP - Incorporating modifications |  | 1d? | 2002-03-12 | 2002-03-12 | 251 | 2001-12-21 | 2001-12-21 | 1d? | 0d |
| 253 | 54.4.7 | GT - HP - Internal review & approval |  | 1d? | 2002-03-13 | 2002-03-13 | 252 | 2001-12-24 | 2001-12-24 | 1d? | 0d |
| 254 | 54.4.8 | GT - HP - Client review |  | 1d? | 2002-03-14 | 2002-03-14 | 253 | 2001-12-25 | 2001-12-25 | 1d? | 0d |
| 255 | 54.4.9 | GT - HP - Incorporating Client modifications |  | 1d? | 2002-03-15 | 2002-03-15 | 254 | 2001-12-26 | 2001-12-26 | 1d? | 0d |
| 256 | 54.4.10 | GT - HP - Internal review & approval |  | 1d? | 2002-03-18 | 2002-03-18 | 255 | 2001-12-27 | 2001-12-27 | 1d? | 0d |
| 257 | 54.4.11 | GT - HP -Client review & approval |  | 1d? | 2002-03-19 | 2002-03-19 | 256 | 2001-12-28 | 2001-12-28 | 1d? | 0d |
| 258 | 54.4.12 | GT - HP - Sign off | milestone | 0d | 2002-03-19 | 2002-03-19 | 257 | 2001-12-31 | 2001-12-31 | 1d? | 0d |
| 259 | 54.4.13 | GT - SP 1 - Creation of Template Designs |  | 1d? | 2002-03-20 | 2002-03-20 | 258 | 2002-01-01 | 2002-01-01 | 1d? | 0d |
| 260 | 54.4.14 | GT - SP 1 - Internal Review by B & UI |  | 1d? | 2002-03-21 | 2002-03-21 | 259 | 2002-01-02 | 2002-01-02 | 1d? | 0d |
| 261 | 54.4.15 | GT - SP 1 - Internal review by Development |  | 1d? | 2002-03-22 | 2002-03-22 | 260 | 2002-01-03 | 2002-01-03 | 1d? | 0d |
| 262 | 54.4.16 | GT - SP 1 - Incorporating modifications |  | 1d? | 2002-03-25 | 2002-03-25 | 261 | 2002-01-04 | 2002-01-04 | 1d? | 0d |
| 263 | 54.4.17 | GT - SP 1 - Internal review & approval |  | 1d? | 2002-03-26 | 2002-03-26 | 262 | 2002-01-07 | 2002-01-07 | 1d? | 0d |
| 264 | 54.4.18 | GT - SP 1 - Client review |  | 1d? | 2002-03-27 | 2002-03-27 | 263 | 2002-01-08 | 2002-01-08 | 1d? | 0d |
| 265 | 54.4.19 | GT - SP 1 - Incorporating Client modifications |  | 1d? | 2002-03-28 | 2002-03-28 | 264 | 2002-01-09 | 2002-01-09 | 1d? | 0d |
| 266 | 54.4.20 | GT - SP 1 - Internal review & approval |  | 1d? | 2002-03-29 | 2002-03-29 | 265 | 2002-01-10 | 2002-01-10 | 1d? | 0d |
| 267 | 54.4.21 | GT - SP 1 - Client review & approval |  | 1d? | 2002-04-01 | 2002-04-01 | 266 | 2002-01-11 | 2002-01-11 | 1d? | 0d |
| 268 | 54.4.22 | GT - SP 2 - Creation of Template Designs |  | 1d? | 2002-03-20 | 2002-03-20 | 258 | 2002-01-01 | 2002-01-01 | 1d? | 0d |
| 269 | 54.4.23 | GT - SP 2 - Internal Review by B & UI |  | 1d? | 2002-03-21 | 2002-03-21 | 268 | 2002-01-02 | 2002-01-02 | 1d? | 0d |
| 270 | 54.4.24 | GT - SP 2 - Internal review by Development |  | 1d? | 2002-03-22 | 2002-03-22 | 269 | 2002-01-03 | 2002-01-03 | 1d? | 0d |
| 271 | 54.4.25 | GT - SP 2 - Incorporating modifications |  | 1d? | 2002-03-25 | 2002-03-25 | 270 | 2002-01-04 | 2002-01-04 | 1d? | 0d |
| 272 | 54.4.26 | GT - SP 2 - Internal review & approval |  | 1d? | 2002-03-26 | 2002-03-26 | 271 | 2002-01-07 | 2002-01-07 | 1d? | 0d |
| 273 | 54.4.27 | GT - SP 2 - Client review |  | 1d? | 2002-03-27 | 2002-03-27 | 272 | 2002-01-08 | 2002-01-08 | 1d? | 0d |
| 274 | 54.4.28 | GT - SP 2 - Incorporating Client modifications |  | 1d? | 2002-03-28 | 2002-03-28 | 273 | 2002-01-09 | 2002-01-09 | 1d? | 0d |
| 275 | 54.4.29 | GT - SP 2 - Internal review & approval |  | 1d? | 2002-03-29 | 2002-03-29 | 274 | 2002-01-10 | 2002-01-10 | 1d? | 0d |
| 276 | 54.4.30 | GT - SP 2 - Client review & approval |  | 1d? | 2002-04-01 | 2002-04-01 | 275 | 2002-01-11 | 2002-01-11 | 1d? | 0d |
| 277 | 54.4.31 | GT - SP - Sign off | milestone | 0d | 2002-04-01 | 2002-04-01 | 267, 276 | 2002-01-14 | 2002-01-14 | 1d? | 0d |
| 278 | 54.4.32 | Go To Content - Procurement / Creation ! |  | 8h? | 2002-01-01 | 2002-01-02 |  |  |  |  | 125.88d |

| ID | WBS | Task | Type | Duration | Start | Finish | Predecessors | Baseline start | Baseline finish | Baseline duration | Total slack | Free slack | Constraint | Calendar |
| --- | --- | --- | --- | --- | --- | --- | --- | --- | --- | --- | --- | --- | --- | --- |
| 279 | 54.5 | **TP** |  | 35.88d? | 2002-01-01 | 2002-02-19 |  |  |  |  | 25d |  |  |  |
| 280 | 54.5.1 | **TP - Client review** |  | 3d? | 2002-02-04 | 2002-02-07 |  |  |  |  | 0.12d |  |  | NG - Day shift |
| 281 | 54.5.1.1 | TP - Client review 1 |  | 1d? | 2002-02-04 | 2002-02-05 | 191 |  |  |  | 0.12d | 0d | start no earlier than 2002-01-01 | NG - Day shift |
| 282 | 54.5.1.2 | TP - Client review 2 |  | 1d? | 2002-02-05 | 2002-02-06 | 281 |  |  |  | 0.12d | 0d | start no earlier than 2002-01-02 | NG - Day shift |
| 283 | 54.5.1.3 | TP - Client review 3 |  | 1d? | 2002-02-06 | 2002-02-07 | 282 |  |  |  | 0.12d | 0d | start no earlier than 2002-01-03 | NG - Day shift |
| 284 | 54.5.2 | **TP - Client review & approval** |  | 3d? | 2002-02-11 | 2002-02-14 |  |  |  |  | 5.12d |  |  | NG - Day shift |
| 285 | 54.5.2.1 | TP - Client review & approval 1 |  | 1d? | 2002-02-11 | 2002-02-12 | 193 |  |  |  | 5.12d | 0d | start no earlier than 2002-01-01 | NG - Day shift |
| 286 | 54.5.2.2 | TP - Client review & approval 2 |  | 1d? | 2002-02-12 | 2002-02-13 | 285 |  |  |  | 5.12d | 0d | start no earlier than 2002-01-02 | NG - Day shift |
| 287 | 54.5.2.3 | TP - Client review & approval 3 |  | 1d? | 2002-02-13 | 2002-02-14 | 286 |  |  |  | 5.12d | 0d | start no earlier than 2002-01-03 | NG - Day shift |
| 288 | 54.5.3 | TP - Phase sign off | milestone | 0d | 2002-02-14 | 2002-02-14 | 287 | 2001-10-29 | 2001-10-29 | 0d | 4d | 0d |  |  |
| 289 | 54.5.4 | **TP - Follow-up for phase payment** |  | 4d? | 2002-02-14 | 2002-02-19 |  | 2001-11-13 | 2001-11-16 | 4d? | 100d |  |  | NG - Day shift |
| 290 | 54.5.4.1 | TP - Follow-up for phase payment 1 |  | 1d? | 2002-02-14 | 2002-02-15 | 288 | 2001-11-13 | 2001-11-13 | 1d? | 100d | 0d | start no earlier than 2002-01-01 | NG - Day shift |
| 291 | 54.5.4.2 | TP - Follow-up for phase payment 2 |  | 1d? | 2002-02-15 | 2002-02-16 | 290 | 2001-11-14 | 2001-11-14 | 1d? | 100d | 0d | start no earlier than 2002-01-02 | NG - Day shift |
| 292 | 54.5.4.3 | TP - Follow-up for phase payment 3 |  | 1d? | 2002-02-16 | 2002-02-18 | 291 | 2001-11-15 | 2001-11-15 | 1d? | 100d | 0d | start no earlier than 2002-01-03 | NG - Day shift |
| 293 | 54.5.4.4 | TP - Follow-up for phase payment 4 |  | 1d? | 2002-02-18 | 2002-02-19 | 292 | 2001-11-16 | 2001-11-16 | 1d? | 100d | 0d | start no earlier than 2002-01-04 | NG - Day shift |
| 294 | 54.5.5 | TP - Phase payment received | milestone | 0d | 2002-02-19 | 2002-02-19 | 293 | 2001-11-16 | 2001-11-16 | 0d | 91d |  |  |  |
| 295 | 54.5.6 | Go To FS - Preparation ! |  | 8h? | 2002-01-01 | 2002-01-02 |  |  |  |  | 125.88d |  |  |  |
| 296 | 54.6 | **FS** |  | 35.88d? | 2002-01-01 | 2002-02-19 |  |  |  |  | 91d |  |  |  |
| 297 | 54.6.1 | FS - Phase sign off | milestone | 0d | 2002-02-14 | 2002-02-14 | 195 | 2001-10-29 | 2001-10-29 | 0d | 91d | 0d |  |  |
| 298 | 54.6.2 | **FS - Follow-up for phase payment** |  | 4d? | 2002-02-14 | 2002-02-19 |  | 2001-11-16 | 2001-11-21 | 4d? | 100d |  |  | NG - Day shift |
| 299 | 54.6.2.1 | FS - Follow-up for phase payment 1 |  | 1d? | 2002-02-14 | 2002-02-15 | 297 | 2001-11-16 | 2001-11-16 | 1d? | 100d | 0d | start no earlier than 2002-01-01 | NG - Day shift |
| 300 | 54.6.2.2 | FS - Follow-up for phase payment 2 |  | 1d? | 2002-02-15 | 2002-02-16 | 299 | 2001-11-19 | 2001-11-19 | 1d? | 100d | 0d | start no earlier than 2002-01-02 | NG - Day shift |
| 301 | 54.6.2.3 | FS - Follow-up for phase payment 3 |  | 1d? | 2002-02-16 | 2002-02-18 | 300 | 2001-11-20 | 2001-11-20 | 1d? | 100d | 0d | start no earlier than 2002-01-03 | NG - Day shift |
| 302 | 54.6.2.4 | FS - Follow-up for phase payment 4 |  | 1d? | 2002-02-18 | 2002-02-19 | 301 | 2001-11-21 | 2001-11-21 | 1d? | 100d | 0d | start no earlier than 2002-01-04 | NG - Day shift |
| 303 | 54.6.3 | FS - Phase payment received | milestone | 0d | 2002-02-19 | 2002-02-19 | 302 | 2001-11-21 | 2001-11-21 | 0d | 91d |  |  |  |
| 304 | 54.6.4 | Go To Visualization - Preparation of the storyboard ! |  | 8h? | 2002-01-01 | 2002-01-02 |  |  |  |  | 125.88d |  |  |  |

| ID | WBS | Task | Type | Duration | Start | Finish | Predecessors | Baseline start | Baseline finish | Baseline duration | Total slack | Free slack | Constraint | Calendar |
| --- | --- | --- | --- | --- | --- | --- | --- | --- | --- | --- | --- | --- | --- | --- |
| 305 | 54.7 | **DB design** |  | 4d? | 2002-02-15 | 2002-02-20 |  |  |  |  | 40d |  |  |  |
| 306 | 54.7.1 | DB - Preparation |  | 1d? | 2002-02-15 | 2002-02-15 | 288 | 2001-10-29 | 2001-10-29 | 1d? | 40d | 0d |  |  |
| 307 | 54.7.2 | DB - CTO review |  | 1d? | 2002-02-18 | 2002-02-18 | 306 | 2001-10-30 | 2001-10-30 | 1d? | 40d | 0d |  |  |
| 308 | 54.7.3 | DB - Incorporating modifications |  | 1d? | 2002-02-19 | 2002-02-19 | 307 | 2001-10-31 | 2001-10-31 | 1d? | 40d | 0d |  |  |
| 309 | 54.7.4 | DB - CTO review & approval |  | 1d? | 2002-02-20 | 2002-02-20 | 308 | 2001-11-01 | 2001-11-01 | 1d? | 40d | 0d |  |  |
| 310 | 54.8 | DB - design complete | milestone | 0h | 2002-02-20 | 2002-02-20 | 309 | 2001-11-01 | 2001-11-01 | 0h | 40d | 6d |  |  |
| 311 | 54.9 | Go To GP - Preparation ! |  | 8h? | 2002-01-01 | 2002-01-02 |  |  |  |  | 125.88d |  |  |  |
| 312 | 54.10 | **GP** |  | 83.88d? | 2002-01-01 | 2002-04-27 |  |  |  |  | 43d |  |  |  |
| 313 | 54.10.1 | **GP - Client review** |  | 3d? | 2002-04-12 | 2002-04-16 |  |  |  |  | 0.12d |  |  | NG - Day shift |
| 314 | 54.10.1.1 | GP - Client review 1 |  | 1d? | 2002-04-12 | 2002-04-13 | 197 |  |  |  | 0.12d | 0d | start no earlier than 2002-01-01 | NG - Day shift |
| 315 | 54.10.1.2 | GP - Client review 2 |  | 1d? | 2002-04-13 | 2002-04-15 | 314 |  |  |  | 0.12d | 0d | start no earlier than 2002-01-02 | NG - Day shift |
| 316 | 54.10.1.3 | GP - Client review 3 |  | 1d? | 2002-04-15 | 2002-04-16 | 315 |  |  |  | 0.12d | 0d | start no earlier than 2002-01-03 | NG - Day shift |
| 317 | 54.10.2 | **GP - Client review & approval** |  | 3d? | 2002-04-18 | 2002-04-23 |  |  |  |  | 0.12d |  |  | NG - Day shift |
| 318 | 54.10.2.1 | GP - Client review & approval 1 |  | 1d? | 2002-04-18 | 2002-04-19 | 199 |  |  |  | 0.12d | 0d | start no earlier than 2001-10-29 | NG - Day shift |
| 319 | 54.10.2.2 | GP - Client review & approval 2 |  | 1d? | 2002-04-19 | 2002-04-22 | 318 |  |  |  | 0.12d | 0d | start no earlier than 2001-10-30 | NG - Day shift |
| 320 | 54.10.2.3 | GP - Client review & approval 3 |  | 1d? | 2002-04-22 | 2002-04-23 | 319 |  |  |  | 0.12d | 0d | start no earlier than 2001-10-31 | NG - Day shift |
| 321 | 54.10.3 | GP - Phase sign off | milestone | 0h | 2002-04-23 | 2002-04-23 | 320 | 2001-10-29 | 2001-10-29 | 0h | 0d |  |  |  |
| 322 | 54.10.4 | **GP - Follow-up for phase payment** |  | 4d? | 2002-04-23 | 2002-04-27 |  | 2002-01-03 | 2002-01-08 | 4d? | 47d |  |  | NG - Day shift |
| 323 | 54.10.4.1 | GP - Follow-up for phase payment 1 |  | 1d? | 2002-04-23 | 2002-04-24 | 321 | 2002-01-03 | 2002-01-03 | 1d? | 47d | 0d | start no earlier than 2002-01-01 | NG - Day shift |
| 324 | 54.10.4.2 | GP - Follow-up for phase payment 2 |  | 1d? | 2002-04-24 | 2002-04-25 | 323 | 2002-01-04 | 2002-01-04 | 1d? | 47d | 0d | start no earlier than 2002-01-02 | NG - Day shift |
| 325 | 54.10.4.3 | GP - Follow-up for phase payment 3 |  | 1d? | 2002-04-25 | 2002-04-26 | 324 | 2002-01-07 | 2002-01-07 | 1d? | 47d | 0d | start no earlier than 2002-01-03 | NG - Day shift |
| 326 | 54.10.4.4 | GP - Follow-up for phase payment 4 |  | 1d? | 2002-04-26 | 2002-04-27 | 325 | 2002-01-08 | 2002-01-08 | 1d? | 47d | 0d | start no earlier than 2002-01-04 | NG - Day shift |
| 327 | 54.10.5 | GP - Phase payment received | milestone | 0d | 2002-04-27 | 2002-04-27 | 326 | 2002-01-08 | 2002-01-08 | 0d | 43d |  |  |  |
| 328 | 54.10.6 | Go To TS - Preparation ! |  | 8h? | 2002-01-01 | 2002-01-02 |  |  |  |  | 125.88d |  |  |  |

| ID | WBS | Task | Type | Duration | Start | Finish | Predecessors | Baseline start | Baseline finish | Baseline duration | Total slack |
| --- | --- | --- | --- | --- | --- | --- | --- | --- | --- | --- | --- |
| 329 | 54.11 | **Testing** |  | 22d? | 2002-05-13 | 2002-06-11 |  |  |  |  | 0d |
| 330 | 54.11.1 | **Integration testing** |  | 3d? | 2002-05-13 | 2002-05-15 |  |  |  |  | 0d |
| 331 | 54.11.1.1 | Integration testing - by QC |  | 1d? | 2002-05-13 | 2002-05-13 | 204 | 2001-10-29 | 2001-10-29 | 1d? | 0d |
| 332 | 54.11.1.2 | Bug fixing by Development |  | 1d? | 2002-05-14 | 2002-05-14 | 331 | 2001-10-30 | 2001-10-30 | 1d? | 0d |
| 333 | 54.11.1.3 | Retesting by QC |  | 1d? | 2002-05-15 | 2002-05-15 | 332 | 2001-10-31 | 2001-10-31 | 1d? | 0d |
| 334 | 54.11.2 | Integration testing - complete | milestone | 0h | 2002-05-15 | 2002-05-15 | 333 | 2001-10-31 | 2001-10-31 | 0h | 0d |
| 335 | 54.11.3 | **Product testing** |  | 3d? | 2002-05-16 | 2002-05-20 |  |  |  |  | 0d |
| 336 | 54.11.3.1 | Product testing - by QC |  | 1d? | 2002-05-16 | 2002-05-16 | 334 | 2001-11-01 | 2001-11-01 | 1d? | 0d |
| 337 | 54.11.3.2 | Bug fixing by Development |  | 1d? | 2002-05-17 | 2002-05-17 | 336 | 2001-11-02 | 2001-11-02 | 1d? | 0d |
| 338 | 54.11.3.3 | Retesting by QC |  | 1d? | 2002-05-20 | 2002-05-20 | 337 | 2001-11-05 | 2001-11-05 | 1d? | 0d |
| 339 | 54.11.4 | Product testing - complete | milestone | 0h | 2002-05-20 | 2002-05-20 | 338 | 2001-11-05 | 2001-11-05 | 0h | 0d |
| 340 | 54.11.5 | **Beta testing** |  | 7d? | 2002-05-21 | 2002-05-29 |  |  |  |  | 0d |
| 341 | 54.11.5.1 | Beta testing - by QC |  | 1d? | 2002-05-21 | 2002-05-21 | 339 | 2001-11-06 | 2001-11-06 | 1d? | 0d |
| 342 | 54.11.5.2 | Beta testing - QC bug fixing |  | 1d? | 2002-05-22 | 2002-05-22 | 341 | 2001-11-07 | 2001-11-07 | 1d? | 0d |
| 343 | 54.11.5.3 | Beta testing - retesting by QC |  | 1d? | 2002-05-23 | 2002-05-23 | 342 | 2001-11-08 | 2001-11-08 | 1d? | 0d |
| 344 | 54.11.5.4 | Beta testing - by Client |  | 1d? | 2002-05-24 | 2002-05-24 | 343 | 2001-11-09 | 2001-11-09 | 1d? | 0d |
| 345 | 54.11.5.5 | Beta testing - Client bug fixing |  | 1d? | 2002-05-27 | 2002-05-27 | 344 | 2001-11-12 | 2001-11-12 | 1d? | 0d |
| 346 | 54.11.5.6 | Beta testing - retesting by QC |  | 1d? | 2002-05-28 | 2002-05-28 | 345 | 2001-11-13 | 2001-11-13 | 1d? | 0d |
| 347 | 54.11.5.7 | Beta testing - Retesting by Client |  | 1d? | 2002-05-29 | 2002-05-29 | 346 | 2001-11-14 | 2001-11-14 | 1d? | 0d |
| 348 | 54.11.6 | Beta testing - complete | milestone | 0h | 2002-05-29 | 2002-05-29 | 347 | 2001-11-14 | 2001-11-14 | 0h | 0d |
| 349 | 54.11.7 | **Acceptance testing** |  | 6d? | 2002-05-30 | 2002-06-06 |  |  |  |  | 0d |
| 350 | 54.11.7.1 | Acceptance testing - by QC |  | 1d? | 2002-05-30 | 2002-05-30 | 348 | 2001-11-16 | 2001-11-16 | 1d? | 0d |
| 351 | 54.11.7.2 | Acceptance testing - QC bug fixing |  | 1d? | 2002-05-31 | 2002-05-31 | 350 | 2001-11-19 | 2001-11-19 | 1d? | 0d |
| 352 | 54.11.7.3 | Acceptance testing - retesting by QC |  | 1d? | 2002-06-03 | 2002-06-03 | 351 | 2001-11-20 | 2001-11-20 | 1d? | 0d |
| 353 | 54.11.7.4 | Acceptance testing - by Client |  | 1d? | 2002-06-04 | 2002-06-04 | 352 | 2001-11-21 | 2001-11-21 | 1d? | 0d |
| 354 | 54.11.7.5 | Acceptance testing - Client bug fixing |  | 1d? | 2002-06-05 | 2002-06-05 | 353 | 2001-11-22 | 2001-11-22 | 1d? | 0d |
| 355 | 54.11.7.6 | Acceptance testing - retesting by QC |  | 1d? | 2002-06-06 | 2002-06-06 | 354 | 2001-11-23 | 2001-11-23 | 1d? | 0d |
| 356 | 54.11.8 | Acceptance testing - By Client - Complete | milestone | 0h | 2002-06-06 | 2002-06-06 | 355 | 2001-11-23 | 2001-11-23 | 0h | 0d |

| ID | WBS | Task | Type | Duration | Start | Finish | Predecessors | Baseline start | Baseline finish | Baseline duration | Total slack | Free slack | Constraint | Calendar |
| --- | --- | --- | --- | --- | --- | --- | --- | --- | --- | --- | --- | --- | --- | --- |
| 357 | 54.11.9 | **Acceptance testing - Follow-up for phase payment** |  | 4d? | 2002-06-06 | 2002-06-11 |  | 2002-01-21 | 2002-01-24 | 4d? | 12d |  |  | NG - Day shift |
| 358 | 54.11.9.1 | Acceptance testing - Follow-up for phase payment 1 |  | 1d? | 2002-06-06 | 2002-06-07 | 356 | 2002-01-21 | 2002-01-21 | 1d? | 12d | 0d | start no earlier than 2002-01-01 | NG - Day shift |
| 359 | 54.11.9.2 | Acceptance testing - Follow-up for phase payment 2 |  | 1d? | 2002-06-07 | 2002-06-08 | 358 | 2002-01-22 | 2002-01-22 | 1d? | 12d | 0d | start no earlier than 2002-01-02 | NG - Day shift |
| 360 | 54.11.9.3 | Acceptance testing - Follow-up for phase payment 3 |  | 1d? | 2002-06-08 | 2002-06-10 | 359 | 2002-01-23 | 2002-01-23 | 1d? | 12d | 0d | start no earlier than 2002-01-03 | NG - Day shift |
| 361 | 54.11.9.4 | Acceptance testing - Follow-up for phase payment 4 |  | 1d? | 2002-06-10 | 2002-06-11 | 360 | 2002-01-24 | 2002-01-24 | 1d? | 12d | 0d | start no earlier than 2002-01-04 | NG - Day shift |
| 362 | 54.11.10 | Acceptance testing - Phase payment received | milestone | 0d | 2002-06-11 | 2002-06-11 | 361 | 2002-01-24 | 2002-01-24 | 0d | 11d |  |  |  |
| 363 | 54.12 | **Project sign off** |  | 14d? | 2002-06-07 | 2002-06-26 |  |  |  |  | 0d |  |  |  |
| 364 | 54.12.1 | Project sign off - Product delivery |  | 1d? | 2002-06-07 | 2002-06-07 | 356 | 2001-11-26 | 2001-11-26 | 1d? | 0d |  |  |  |
| 365 | 54.12.2 | Project sign off - Final sign off | milestone | 0d | 2002-06-07 | 2002-06-07 | 364 | 2001-11-27 | 2001-11-27 | 1d? | 0d |  |  |  |
| 366 | 54.12.3 | **Project sign off - Follow-up for final payment** |  | 15d? | 2002-06-07 | 2002-06-26 |  | 2002-01-24 | 2002-02-13 | 15d? | 0d |  |  | NG - Day shift |
| 367 | 54.12.3.1 | Project sign off - Follow-up for final payment 1 |  | 1d? | 2002-06-07 | 2002-06-08 | 365 | 2002-01-24 | 2002-01-24 | 1d? | 0d |  | start no earlier than 2002-01-01 | NG - Day shift |
| 368 | 54.12.3.2 | Project sign off - Follow-up for final payment 2 |  | 1d? | 2002-06-08 | 2002-06-10 | 367 | 2002-01-25 | 2002-01-25 | 1d? | 0d |  | start no earlier than 2002-01-02 | NG - Day shift |
| 369 | 54.12.3.3 | Project sign off - Follow-up for final payment 3 |  | 1d? | 2002-06-10 | 2002-06-11 | 368 | 2002-01-28 | 2002-01-28 | 1d? | 0d |  | start no earlier than 2002-01-03 | NG - Day shift |
| 370 | 54.12.3.4 | Project sign off - Follow-up for final payment 4 |  | 1d? | 2002-06-11 | 2002-06-12 | 369 | 2002-01-29 | 2002-01-29 | 1d? | 0d |  | start no earlier than 2002-01-04 | NG - Day shift |
| 371 | 54.12.3.5 | Project sign off - Follow-up for final payment 5 |  | 1d? | 2002-06-12 | 2002-06-13 | 370 | 2002-01-30 | 2002-01-30 | 1d? | 0d |  | start no earlier than 2002-01-05 | NG - Day shift |
| 372 | 54.12.3.6 | Project sign off - Follow-up for final payment 6 |  | 1d? | 2002-06-13 | 2002-06-14 | 371 | 2002-01-31 | 2002-01-31 | 1d? | 0d |  | start no earlier than 2002-01-07 | NG - Day shift |
| 373 | 54.12.3.7 | Project sign off - Follow-up for final payment 7 |  | 1d? | 2002-06-14 | 2002-06-17 | 372 | 2002-02-01 | 2002-02-01 | 1d? | 0d |  | start no earlier than 2002-01-08 | NG - Day shift |
| 374 | 54.12.3.8 | Project sign off - Follow-up for final payment 8 |  | 1d? | 2002-06-17 | 2002-06-18 | 373 | 2002-02-04 | 2002-02-04 | 1d? | 0d |  | start no earlier than 2002-01-09 | NG - Day shift |
| 375 | 54.12.3.9 | Project sign off - Follow-up for final payment 9 |  | 1d? | 2002-06-18 | 2002-06-19 | 374 | 2002-02-05 | 2002-02-05 | 1d? | 0d |  | start no earlier than 2002-01-10 | NG - Day shift |
| 376 | 54.12.3.10 | Project sign off - Follow-up for final payment 10 |  | 1d? | 2002-06-19 | 2002-06-20 | 375 | 2002-02-06 | 2002-02-06 | 1d? | 0d |  | start no earlier than 2002-01-11 | NG - Day shift |
| 377 | 54.12.3.11 | Project sign off - Follow-up for final payment 11 |  | 1d? | 2002-06-20 | 2002-06-21 | 376 | 2002-02-07 | 2002-02-07 | 1d? | 0d |  | start no earlier than 2002-01-14 | NG - Day shift |
| 378 | 54.12.3.12 | Project sign off - Follow-up for final payment 12 |  | 1d? | 2002-06-21 | 2002-06-22 | 377 | 2002-02-08 | 2002-02-08 | 1d? | 0d |  | start no earlier than 2002-01-15 | NG - Day shift |
| 379 | 54.12.3.13 | Project sign off - Follow-up for final payment 13 |  | 1d? | 2002-06-22 | 2002-06-24 | 378 | 2002-02-11 | 2002-02-11 | 1d? | 0d |  | start no earlier than 2002-01-16 | NG - Day shift |
| 380 | 54.12.3.14 | Project sign off - Follow-up for final payment 14 |  | 1d? | 2002-06-24 | 2002-06-25 | 379 | 2002-02-12 | 2002-02-12 | 1d? | 0d |  | start no earlier than 2002-01-17 | NG - Day shift |
| 381 | 54.12.3.15 | Project sign off - Follow-up for final payment 15 |  | 1d? | 2002-06-25 | 2002-06-26 | 380 | 2002-02-13 | 2002-02-13 | 1d? | 0d |  | start no earlier than 2002-01-18 | NG - Day shift |
| 382 | 54.12.4 | Project sign off - Final payment received | milestone | 0d | 2002-06-26 | 2002-06-26 | 381 | 2002-02-13 | 2002-02-13 | 0d | 0d |  |  |  |
